# vdfs_prog_20030603

Schedule from MS Project, 2003-01-01 to 2005-01-03, scheduled back from the finish, A marks actual dates.
vista data flow system
CASU

## Calendars

- Standard: Mon-Fri 08:00-12:00, 13:00-17:00; Sat-Sun off.

## Schedule

| ID | WBS | Task | Type | Duration | Start | Finish | Complete | Remaining | Baseline start | Baseline finish | Baseline duration | Total slack | Free slack | Constraint | Text1 |
| --- | --- | --- | --- | --- | --- | --- | --- | --- | --- | --- | --- | --- | --- | --- | --- |
| 1 | 1 | **Quarterly Reviews** |  | 461d? | 2003-03-31 | 2005-01-03 |  |  |  |  |  | 63d | 0d | as late as possible |  |
| 2 | 1.1 | Quarterly Review | milestone | 1d? | 2003-03-31 | 2003-03-31 |  |  |  |  |  | 63d | 0d | start no later than 2003-03-31 |  |
| 3 | 1.2 | Quarterly Review | milestone | 1d? | 2003-07-01 | 2003-07-01 |  |  |  |  |  | 129d | 0d | start no later than 2003-07-01 |  |
| 4 | 1.3 | Quarterly Review | milestone | 1d? | 2003-10-01 | 2003-10-01 |  |  |  |  |  | 195d | 0d | start no later than 2003-10-01 |  |
| 5 | 1.4 | Quarterly Review | milestone | 1d? | 2004-01-01 | 2004-01-01 |  |  |  |  |  | 261d | 0d | start no later than 2004-01-01 |  |
| 6 | 1.5 | Quarterly Review | milestone | 1d? | 2004-04-01 | 2004-04-01 |  |  |  |  |  | 326d | 0d | start no later than 2004-04-01 |  |
| 7 | 1.6 | Quarterly Review | milestone | 1d? | 2004-07-01 | 2004-07-01 |  |  |  |  |  | 391d | 0d | start no later than 2004-07-01 |  |
| 8 | 1.7 | Quarterly Review | milestone | 1d? | 2004-10-01 | 2004-10-01 |  |  |  |  |  | 457d | 0d | start no later than 2004-10-01 |  |
| 9 | 1.8 | Quarterly Review | milestone | 1d? | 2005-01-01 | 2005-01-03 |  |  |  |  |  | 523d | 0d | start no later than 2005-01-01 |  |
| 10 | 2 | **Management and Defenition of Responsibilities** |  | 523d? | 2003-01-01 A | 2004-12-31 | 40% | 314.2d? | 2003-01-01 | 2003-12-31 | 261d | 261d | 0d | as late as possible |  |
| 11 | 2.1 | 2003 |  | 261d? | 2003-01-01 A | 2003-12-31 | 80% | 52.2d? |  |  |  | 0d |  | finish no later than 2003-12-31 |  |
| 12 | 2.2 | 2004 |  | 262d? | 2004-01-01 | 2004-12-31 |  |  |  |  |  | 261d | 0d | as late as possible |  |
| 13 | 3 | Fits headers and data structures defention document | milestone | 1d? | 2003-07-01 | 2003-07-01 |  |  |  |  |  | 129d | 0d | finish no later than 2003-07-01 | D1c |
| 14 | 4 | ICD between CASU and WFAU | milestone | 1d? | 2003-10-01 | 2003-10-01 |  |  |  |  |  | 195d | 0d | start no later than 2003-10-01 | D1b |
| 15 | 5 | ICD between CASU and JAC | milestone | 1d? | 2003-12-31 | 2003-12-31 |  |  |  |  |  | 260d | 0d | start no later than 2003-12-31 | D1a |
| 16 | 6 | **ESO VISTA software deliverables and documentation** |  | 523d? | 2003-01-01 A | 2004-12-31 | 37% | 327.25d? | 2003-01-01 | 2004-12-31 | 523d? | 261d | 0d | as late as possible |  |
| 17 | 6.1 | 2003 |  | 261d? | 2003-01-01 A | 2003-12-31 | 75% | 65.25d? |  |  |  | 0d |  | finish no later than 2003-12-31 |  |
| 18 | 6.2 | 2004 |  | 262d? | 2004-01-01 | 2004-12-31 |  |  |  |  |  | 261d | 0d | as late as possible |  |
| 19 | 7 | Calibration plan document | milestone | 1d? | 2003-12-19 | 2003-12-19 |  |  |  |  |  | 252d | 0d | finish no later than 2003-12-19 | D2a |
| 20 | 8 | Data reduction specification | milestone | 1d? | 2003-12-19 | 2003-12-19 |  |  |  |  |  | 252d | 0d | finish no later than 2003-12-19 | D2b |
| 21 | 9 | DFS user requirements document | milestone | 1d? | 2003-12-19 | 2003-12-19 |  |  |  |  |  | 252d | 0d | finish no later than 2003-12-19 | D2c |
| 22 | 10 | **Pipeline Infrastructure and Progress Monitoring Tools** |  | 523d? | 2003-01-01 A | 2004-12-31 | 50% | 261.8d? | 2003-01-01 | 2004-12-31 | 523d? | 0d |  | as late as possible |  |
| 23 | 10.1 | 2003 |  | 261d? | 2003-01-01 A | 2003-12-31 | 80% | 52.2d? |  |  |  | 0d |  | finish no later than 2003-12-31 |  |
| 24 | 10.2 | 2004 |  | 262d? | 2004-01-01 A | 2004-12-31 | 20% | 209.6d? |  |  |  | 0d |  | as late as possible |  |
| 25 | 11 | Deliver pipeline V1.0 | milestone | 1d? | 2003-12-31 | 2003-12-31 |  |  |  |  |  | 260d | 0d | finish no later than 2003-12-31 | D3a |
| 26 | 12 | Deliver documentation for pipeline V1.0 | milestone | 1d? | 2003-12-31 | 2003-12-31 |  |  |  |  |  | 260d | 0d | finish no later than 2003-12-31 | D3b |

| ID | WBS | Task | Type | Duration | Start | Finish | Complete | Remaining | Baseline start | Baseline finish | Baseline duration | Total slack | Free slack | Constraint | Text1 |
| --- | --- | --- | --- | --- | --- | --- | --- | --- | --- | --- | --- | --- | --- | --- | --- |
| 27 | 13 | **Set up and Manage Raw Science Archive** |  | 328d? | 2003-10-01 | 2004-12-31 |  |  | 2003-10-01 | 2004-12-31 | 328d? | 195d | 0d | as late as possible |  |
| 28 | 13.1 | 2003 |  | 66d? | 2003-10-01 | 2003-12-31 |  |  |  |  |  | 195d | 0d | start no later than 2003-10-01 |  |
| 29 | 13.2 | 2004 |  | 262d? | 2004-01-01 | 2004-12-31 |  |  |  |  |  | 261d | 0d | as late as possible |  |
| 30 | 14 | Create Raw Science Archive | milestone | 1d? | 2004-02-01 | 2004-02-02 |  |  |  |  |  | 283d | 0d | start no later than 2004-02-01 | D4a |
| 31 | 15 | **Set up and Manage Data Processing System Hardware** |  | 523d? | 2003-01-01 A | 2004-12-31 | 25% | 392.5d? | 2003-01-01 | 2004-12-31 | 523d? | 261d | 0d | as late as possible |  |
| 32 | 15.1 | 2003 |  | 261d? | 2003-01-01 A | 2003-12-31 | 50% | 130.5d? |  |  |  | 0d |  | finish no later than 2003-12-31 |  |
| 33 | 15.2 | 2004 |  | 262d? | 2004-01-01 | 2004-12-31 |  |  |  |  |  | 261d | 0d | as late as possible |  |
| 34 | 16 | Processing hardware in place | milestone | 1d? | 2003-12-31 | 2003-12-31 |  |  |  |  |  | 260d | 0d | finish no later than 2003-12-31 | D5a |
| 35 | 17 | **Run Standard Pipeline** |  | 262d? | 2004-01-01 | 2004-12-31 |  |  | 2004-01-01 | 2004-12-31 | 262d? | 261d | 0d | as late as possible |  |
| 36 | 17.1 | 2004 |  | 262d? | 2004-01-01 | 2004-12-31 |  |  |  |  |  | 261d | 0d | as late as possible |  |
| 37 | 18 | Data flow to WFAU initiated | milestone | 0d? | 2004-02-01 | 2004-02-01 |  |  |  |  |  | 283d | 0d | finish no later than 2004-02-01 | D6a |
| 38 | 19 | **Development Work for Summit Pipeline** |  | 523d? | 2003-01-01 A | 2004-12-31 | 43% | 300.65d? | 2003-01-01 | 2004-12-31 | 523d? | 0d |  | as late as possible |  |
| 39 | 19.1 | 2003 |  | 261d? | 2003-01-01 A | 2003-12-31 | 85% | 39.15d? |  |  |  | 0d |  | finish no later than 2003-12-31 |  |
| 40 | 19.2 | 2004 |  | 262d? | 2004-01-01 A | 2004-12-31 |  | 261.5d? |  |  |  | 0d |  | as late as possible |  |
| 41 | 20 | Deliver summit pipeline | milestone | 1d? | 2003-12-31 | 2003-12-31 |  |  |  |  |  | 260d | 0d | finish no later than 2003-12-31 | D7a |
| 42 | 21 | Deliver summit pipeline documentation | milestone | 1d? | 2003-12-31 | 2003-12-31 |  |  |  |  |  | 260d | 0d | finish no later than 2003-12-31 | D7b |
| 43 | 22 | **Development and Testing of Standard 2D Processing** |  | 457d? | 2003-01-01 A | 2004-09-30 | 40% | 274.3d? | 2003-01-01 | 2004-09-30 | 457d? | 196d | 0d | as late as possible |  |
| 44 | 22.1 | 2003 |  | 261d? | 2003-01-01 A | 2003-12-31 | 70% | 78.3d? |  |  |  | 0d |  | finish no later than 2003-12-31 |  |
| 45 | 22.2 | 2004 |  | 196d? | 2004-01-01 | 2004-09-30 |  |  |  |  |  | 261d | 0d | start no later than 2004-01-01 |  |
| 46 | 23 | Complete 2D processing modules V1.0 | milestone | 23d? | 2003-12-31 | 2004-01-30 |  |  |  |  |  | 260d | 0d | finish no later than 2004-01-31 | D8a |
| 47 | 24 | **Development and Testing of Standard Catalogue Products** |  | 523d? | 2003-01-01 A | 2004-12-31 | 44% | 293.27d? | 2003-01-01 | 2004-12-31 | 523d? | 0d |  | as late as possible |  |
| 48 | 24.1 | 2003 |  | 261d? | 2003-01-01 A | 2003-12-31 | 83% | 44.37d? |  |  |  | 0d |  | finish no later than 2003-12-31 |  |
| 49 | 24.2 | 2004 |  | 262d? | 2004-01-01 A | 2004-12-31 | 5% | 248.9d? |  |  |  | 0d |  | as late as possible |  |
| 50 | 25 | Complete standard catalogue modules V1.0 | milestone | 23d? | 2003-12-31 | 2004-01-30 |  |  |  |  |  | 260d | 0d | finish no later than 2004-01-31 | D9a |

| ID | WBS | Task | Type | Duration | Start | Finish | Complete | Remaining | Baseline start | Baseline finish | Baseline duration | Total slack | Free slack | Constraint | Text1 |
| --- | --- | --- | --- | --- | --- | --- | --- | --- | --- | --- | --- | --- | --- | --- | --- |
| 51 | 26 | **Set Up, Trial and Run Further Processing Software** |  | 328d? | 2003-10-01 | 2004-12-31 |  |  | 2003-01-01 | 2004-12-31 | 523d? | 195d | 0d | as late as possible | 10 |
| 52 | 26.1 | 2003 |  | 66d? | 2003-10-01 | 2003-12-31 |  |  |  |  |  | 195d | 0d | start no later than 2003-10-01 |  |
| 53 | 26.2 | 2004 |  | 262d? | 2004-01-01 | 2004-12-31 |  |  |  |  |  | 261d | 0d | as late as possible |  |
| 54 | 27 | Deliver 2D PSF and Sersic fitting applications | milestone | 1d? | 2004-12-31 | 2004-12-31 |  |  |  |  |  | 522d | 0d | as late as possible | D10a |
| 55 | 28 | **Photometric Standards and Calibration** |  | 523d? | 2003-01-01 A | 2004-12-31 | 40% | 314.2d? | 2003-01-01 | 2004-12-31 | 523d? | 261d | 0d | as late as possible | 11 |
| 56 | 28.1 | 2003 |  | 261d? | 2003-01-01 A | 2003-12-31 | 80% | 52.2d? |  |  |  | 0d |  | finish no later than 2003-12-31 |  |
| 57 | 28.2 | 2004 |  | 262d? | 2004-01-01 | 2004-12-31 |  |  |  |  |  | 261d | 0d | as late as possible |  |
| 58 | 29 | Allocate primary and secondary standard stars/fields | milestone | 109d? | 2004-02-01 | 2004-07-01 |  |  |  |  |  | 283d | 0d | start no later than 2004-02-01 | D11a |
| 59 | 30 | Photometric calibration and colour equations (paper) | milestone | 1d? | 2004-08-01 | 2004-08-02 |  |  |  |  |  | 413d | 0d | start no later than 2004-08-01 | D11b |
| 60 | 31 | **Further Development of DQC Measures** |  | 457d? | 2003-01-01 A | 2004-09-30 | 37% | 287.35d? | 2003-01-01 | 2004-09-30 | 457d? | 196d | 0d | as late as possible | 12 |
| 61 | 31.1 | 2003 |  | 261d? | 2003-01-01 A | 2003-12-31 | 65% | 91.35d? |  |  |  | 0d |  | finish no later than 2003-12-31 |  |
| 62 | 31.2 | 2004 |  | 196d? | 2004-01-01 | 2004-09-30 |  |  |  |  |  | 261d | 0d | start no later than 2004-01-01 |  |
| 63 | 32 | **Co-located List Driven Photometry** |  | 523d? | 2003-01-01 A | 2004-12-31 | 30% | 366.4d? | 2003-01-01 | 2004-12-31 | 523d? | 261d | 0d | as late as possible | 13 |
| 64 | 32.1 | 2003 |  | 261d? | 2003-01-01 A | 2003-12-31 | 60% | 104.4d? |  |  |  | 0d |  | finish no later than 2003-12-31 |  |
| 65 | 32.2 | 2004 |  | 262d? | 2004-01-01 | 2004-12-31 |  |  |  |  |  | 261d | 0d | as late as possible |  |
| 66 | 33 | Deliver list driven photometer V1.0 | milestone | 1d? | 2003-12-31 | 2003-12-31 |  |  |  |  |  | 260d | 0d | finish no later than 2003-12-31 | D13a |
| 67 | 34 | **Stacking and Mosaicing** |  | 523d? | 2003-01-01 A | 2004-12-31 | 60% | 209.6d? | 2003-01-01 | 2004-12-31 | 523d? | 0d |  | as late as possible | 14 |
| 68 | 34.1 | 2003 |  | 261d? | 2003-01-01 A | 2003-12-31 A | 100% |  |  |  |  |  |  | finish no later than 2003-12-31 |  |
| 69 | 34.2 | 2004 |  | 262d? | 2004-01-01 A | 2004-12-31 | 20% | 209.6d? |  |  |  | 0d |  | as late as possible |  |
| 70 | 35 | Deliver basic stacker and mosaicer | milestone | 1d? | 2003-09-30 | 2003-09-30 |  |  |  |  |  | 194d | 0d | finish no later than 2003-09-30 | D14 |
| 71 | 36 | **Continuum Subtraction and Basic Difference Imaging** |  | 457d? | 2003-01-01 A | 2004-09-30 | 64% | 165.28d? | 2003-01-01 | 2004-09-30 | 457d? | 0d |  | as late as possible | 15 |
| 72 | 36.1 | 2003 |  | 195d? | 2003-01-01 A | 2003-09-30 A | 100% |  |  |  |  |  |  | finish no later than 2003-09-30 |  |
| 73 | 36.2 | 2004 |  | 131d? | 2004-04-01 A | 2004-09-30 | 10% | 117.9d? |  |  |  | 0d |  | finish no later than 2004-09-30 |  |
| 74 | 37 | **Interpolation Techniques and PSF Modelling** |  | 523d? | 2003-01-01 A | 2004-12-31 | 25% | 392.5d? | 2003-01-01 | 2004-12-31 | 523d? | 261d | 0d | as late as possible | 16 |
| 75 | 37.1 | 2003 |  | 261d? | 2003-01-01 A | 2003-12-31 | 50% | 130.5d? |  |  |  | 0d |  | finish no later than 2003-12-31 |  |
| 76 | 37.2 | 2004 |  | 262d? | 2004-01-01 | 2004-12-31 |  |  |  |  |  | 261d | 0d | as late as possible |  |
| 77 | 38 | Deliver PSF photometer | milestone | 1d? | 2004-12-31 | 2004-12-31 |  |  |  |  |  | 522d | 0d | as late as possible | D16a |
| 79 | 39 | TOTAL PROGRESS |  | 523d? | 2003-01-01 A | 2004-12-31 | 35% | 339.95d? |  |  |  | 0d |  | start no later than 2003-01-01 |  |
